Schedule from GanttProject, 2020-04-22 to 2020-09-09.

## Calendars

- Project calendar: Mon-Fri working; Sat-Sun off.

## Resources

| Resource | Group | Rate |
| --- | --- | --- |
| Jack House |  |  |
| John Black | Excavator operator | 40 |
| Michelangelo | Architect | 1000 |
| Tom White | Bricklayer | 50 |
| Peter Green | Bricklayer | 50 |
| George Brown | Bricklayer | 50 |
| John Silver | Foreman | 100 |

## Schedule

| ID | WBS | Task | Type | Duration | Start | Finish | Predecessors | Complete | Resources |
| --- | --- | --- | --- | --- | --- | --- | --- | --- | --- |
| 1 | 1 | **Architectural design** |  | 25d | 2020-04-22 | 2020-05-26 | 20 | 81% |  |
| 2 | 1.1 | Create draft of architecture |  | 10d | 2020-04-22 | 2020-05-05 |  | 100% | Jack House [50%]; Michelangelo |
| 3 | 1.2 | Prepare construction documents |  | 15d | 2020-05-06 | 2020-05-26 | 2 | 75% | Michelangelo |
| 4 | 1.3 | Agreement on architectural plan | milestone | 0d | 2020-05-27 | 2020-05-27 | 3 |  |  |
| 5 | 2 | **Interior design** |  | 10d | 2020-05-06 | 2020-05-19 |  | 33% |  |
| 6 | 2.1 | Pre-design |  | 5d | 2020-05-06 | 2020-05-12 | 2 | 100% | Jack House; Michelangelo [50%] |
| 7 | 2.2 | Furniture selection |  | 5d | 2020-05-13 | 2020-05-19 | 6 |  | Jack House |
| 8 | 2.3 | Equipment planning |  | 5d | 2020-05-13 | 2020-05-19 | 6 |  | Jack House [50%]; Michelangelo [50%] |
| 9 | 3 | **Construction phase** |  | 75d | 2020-05-27 | 2020-09-08 |  |  |  |
| 10 | 3.1 | Foundation building |  | 15d | 2020-05-27 | 2020-06-16 | 4 |  | John Black; Tom White; George Brown; John Silver |
| 11 | 3.2 | Ground Floor building |  | 20d | 2020-06-17 | 2020-07-14 | 10 |  | Tom White; Peter Green; George Brown; John Silver |
| 12 | 3.3 | First Floor building |  | 20d | 2020-07-15 | 2020-08-11 | 11 |  | Tom White; Peter Green; George Brown; John Silver |
| 13 | 3.4 | Roof |  | 10d | 2020-08-12 | 2020-08-25 | 12 |  | Tom White; John Silver |
| 14 | 3.5 | Connect to communications |  | 10d | 2020-08-26 | 2020-09-08 | 15 |  | John Black; Peter Green |
| 15 | 3.6 | Construction completed | milestone | 0d | 2020-08-26 | 2020-08-26 | 13 |  |  |
| 16 | 4 | **Decoration phase** |  | 10d | 2020-08-26 | 2020-09-08 |  |  |  |
| 17 | 4.1 | Walls |  | 5d | 2020-08-26 | 2020-09-01 | 5, 15 |  | Tom White; Peter Green; George Brown; John Silver |
| 18 | 4.2 | Furniture |  | 3d | 2020-09-02 | 2020-09-04 | 17 |  | Jack House; Tom White |
| 19 | 4.3 | Bring your family here | milestone | 0d | 2020-09-09 | 2020-09-09 | 9, 18 |  |  |
| 20 | 5 | GanttProject 2.8.11 | milestone | 0d | 2020-04-22 | 2020-04-22 |  |  |  |

Notes:
- 8: Embedded devices, kitchen, washing machine, dryer etc
